# Home Construction

Schedule from Primavera P6, 2018-10-09 to 2019-01-22, data date 2018-10-09.

## Calendars

- Calendar 1: Mon off; Tue-Sat 09:00-14:00, 15:00-19:00; Sun off.

## Schedule

| ID | WBS | Activity | Type | Duration | Start | Finish | Predecessors | Total float | Free float |
| --- | --- | --- | --- | --- | --- | --- | --- | --- | --- |
| A1000 |  | Project Start | milestone | 0d | 2018-10-09 | 2018-10-09 |  | 76d | 0d |
| A1010 |  | Project Management | level of effort | 85d | 2018-10-09 | 2019-01-22 | A1000 SS | 0d |  |
| A1020 |  | Project Complete | milestone | 0d | 2019-01-22 | 2019-01-22 | A1010 FF, A1170, A1190, A1230, A1260 | 0d |  |
|  | 1 | **Grading** |  |  | 2018-10-09 | 2018-10-18 |  |  |  |
| A1030 |  | Survey and mark out site |  | 3d | 2018-10-09 | 2018-10-11 | A1000 SS | 76d | 0d |
| A1040 |  | Site Demarcation |  | 1d | 2018-10-11 | 2018-10-12 | A1030 | 76d | 0d |
| A1050 |  | Excavation | resource dependent | 3d | 2018-10-12 | 2018-10-17 | A1040 | 76d | 0d |
| A1060 |  | Grade Site |  | 2d | 2018-10-17 | 2018-10-18 | A1050 | 76d |  |
|  | 2 | **Foundation** |  |  | 2018-10-09 | 2018-10-24 |  |  |  |
| A1070 |  | Laying of Foundation |  | 4d | 2018-10-09 | 2018-10-12 |  | 0d |  |
| A1080 |  | Slab Plumbing |  | 7d | 2018-10-12 | 2018-10-20 | A1070 | 0d |  |
| A1090 |  | Pour and Float Slab Concrete |  | 2d | 2018-10-20 | 2018-10-24 | A1080 | 0d |  |
|  | 3 | **Structure** |  |  | 2018-10-09 | 2019-01-22 |  |  |  |
|  | 1 | **Framing** |  |  | 2018-10-24 | 2018-12-25 |  |  |  |
| A1100 |  | Exterior Walls |  | 20d | 2018-10-24 | 2018-11-17 | A1090 | 0d |  |
| A1110 |  | Interior Walls |  | 25d | 2018-11-17 | 2018-12-19 | A1100 | 27d |  |
| A1120 |  | Exterior Cladding |  | 30d | 2018-11-17 | 2018-12-25 | A1100 | 0d |  |
|  | 2 | **Roof** |  |  | 2018-11-17 | 2018-12-22 |  |  |  |
| A1130 |  | Truss Placing |  | 15d | 2018-11-17 | 2018-12-06 | A1100 | 19d | 0d |
| A1140 |  | Roof Sheeting |  | 10d | 2018-12-06 | 2018-12-19 | A1130 | 19d | 0d |
| A1150 |  | Place Paper and Shingles |  | 3d | 2018-12-19 | 2018-12-22 | A1140 | 19d | 0d |
|  | 3 | **Interior** |  |  | 2018-10-09 | 2018-12-28 |  |  |  |
|  | 1 | **Mechnical** |  |  | 2018-12-22 | 2018-12-28 |  |  |  |
| A1160 |  | HVAC Ducting |  | 3d | 2018-12-22 | 2018-12-26 | A1150 | 19d | 0d |
| A1170 |  | Install HVAC Unit |  | 2d | 2018-12-26 | 2018-12-28 | A1160 | 19d |  |

| ID | WBS | Activity | Duration | Start | Finish | Predecessors | Total float | Free float |
| --- | --- | --- | --- | --- | --- | --- | --- | --- |
|  | 2 | **Electrical** |  | 2018-11-17 | 2018-12-01 |  |  |  |
| A1180 |  | Breaker Box and Rough Wire | 5d | 2018-11-17 | 2018-11-23 | A1100 | 40d | 0d |
| A1190 |  | Finish Wiring | 7d | 2018-11-23 | 2018-12-01 | A1180 | 40d |  |
|  | 3 | **Plumbing** |  | 2018-11-17 | 2018-11-30 |  |  |  |
| A1200 |  | Install Rough plumbing lines | 10d | 2018-11-17 | 2018-11-30 | A1100 | 28d | 0d |
|  | 4 | **Decor** |  | 2018-10-09 | 2018-12-18 |  |  |  |
| A1230 |  | Kitchen Cabinets | 10d | 2018-10-09 | 2018-10-19 |  | 75d |  |
| A1210 |  | Placing Doors | 8d | 2018-11-30 | 2018-12-11 | A1200 | 28d | 0d |
| A1220 |  | Door Placings and Baseboards | 6d | 2018-12-11 | 2018-12-18 | A1210 | 28d |  |
|  | 5 | **Exterior** |  | 2018-12-26 | 2019-01-16 |  |  |  |
| A1240 |  | Place Window | 12d | 2018-12-26 | 2019-01-09 | A1120 | 0d |  |
| A1250 |  | Window Sidings | 5d | 2019-01-09 | 2019-01-16 | A1240 | 0d |  |
|  | 4 | **Landscaping** |  | 2019-01-16 | 2019-01-22 |  |  |  |
| A1260 |  | Tree Plantings | 5d | 2019-01-16 | 2019-01-22 | A1250 | 0d |  |
